# Project Plan Self Assessment

Schedule from MS Project, 2005-01-12 to 2005-10-31.
TUT

## Calendars

- Standard: Mon-Fri 08:00-12:00, 13:00-17:00; Sat-Sun off.

## Resources

| Resource |
| --- |
| Ethney |
| Dhaya |
| Johnny |
| Programme Group |
| Faculty Office |
| DQP |
| DQP(Johnny) |
| Panel Members |
| Betsie |
| Campus Review Committee |

## Schedule

| ID | WBS | Task | Duration | Start | Finish | Total slack | Constraint | Resources | Work |
| --- | --- | --- | --- | --- | --- | --- | --- | --- | --- |
| 1 | 1 | **Campus Review:** | 209d? | 2005-01-12 | 2005-10-31 | 0d |  |  | 5560h |
| 2 | 1.1 | Introduction and Orientation | 10d | 2005-01-12 | 2005-01-25 | 199d |  | DQP | 80h |
| 3 | 1.2 | Consultation and Support | 156d | 2005-01-12 | 2005-08-17 | 53d |  | DQP | 1248h |
| 4 | 1.3 | **Campus Planning and Organization** | 106d? | 2005-01-24 | 2005-06-20 | 95d |  | Campus Review Committee | 3400h |
| 5 | 1.3.1 | Establish review committee | 3d | 2005-01-24 | 2005-01-26 | 198d | start no earlier than 2005-01-24 | Campus Review Committee | 24h |
| 6 | 1.3.2 | Analyse campus review instrument | 10d | 2005-01-24 | 2005-02-04 | 191d | finish no earlier than 2005-02-04 | Campus Review Committee | 80h |
| 7 | 1.3.3 | Determine scope of the review | 10d | 2005-01-24 | 2005-02-04 | 191d | finish no earlier than 2005-02-04 | Campus Review Committee | 80h |
| 8 | 1.3.4 | **Develop project plan** | 5d | 2005-02-07 | 2005-02-11 | 186d |  | Campus Review Committee | 200h |
| 9 | 1.3.4.1 | Identify key tasks | 5d | 2005-02-07 | 2005-02-11 | 186d | finish no earlier than 2005-02-11 | Campus Review Committee | 40h |
| 10 | 1.3.4.2 | Allocate roles and responsibilities | 5d | 2005-02-07 | 2005-02-11 | 186d | finish no earlier than 2005-02-11 | Campus Review Committee | 40h |
| 11 | 1.3.4.3 | Identify and allocate resources | 5d | 2005-02-07 | 2005-02-11 | 186d | finish no earlier than 2005-02-11 | Campus Review Committee | 40h |
| 12 | 1.3.4.4 | Identify targets and milestones | 5d | 2005-02-07 | 2005-02-11 | 186d | finish no earlier than 2005-02-11 | Campus Review Committee | 40h |
| 13 | 1.3.5 | **Information management** | 90d? | 2005-02-14 | 2005-06-17 | 96d |  | Campus Review Committee | 1000h |
| 14 | 1.3.5.1 | Data Collection | 10d | 2005-02-14 | 2005-02-25 | 176d | finish no earlier than 2005-02-25 | Campus Review Committee | 80h |
| 15 | 1.3.5.2 | Data Collation | 10d | 2005-02-28 | 2005-03-11 | 166d | finish no earlier than 2005-03-11 | Campus Review Committee | 80h |
| 16 | 1.3.5.3 | Data Verification | 5d | 2005-03-14 | 2005-03-18 | 161d | finish no earlier than 2005-03-18 | Campus Review Committee | 40h |
| 17 | 1.3.5.4 | Supporting Evidence | 10d | 2005-03-21 | 2005-04-01 | 151d | finish no earlier than 2005-04-01 | Campus Review Committee | 80h |
| 18 | 1.3.5.5 | Make judgements on the basis of assembled information and evidence | 60d? | 2005-03-28 | 2005-06-17 | 96d | start no earlier than 2005-03-27 |  |  |
| 19 | 1.3.6 | **Portfolio Development** | 91d | 2005-02-14 | 2005-06-20 | 95d |  | Campus Review Committee | 1168h |
| 20 | 1.3.6.1 | Allocation of writing tasks | 1d | 2005-02-14 | 2005-02-14 | 185d | start no earlier than 2005-02-14 | Campus Review Committee | 8h |
| 21 | 1.3.6.2 | Writing of various sections | 15d | 2005-04-04 | 2005-04-22 | 136d | start no earlier than 2005-04-04 | Campus Review Committee | 120h |
| 22 | 1.3.6.3 | Consolidation of first draft | 5d | 2005-04-25 | 2005-04-29 | 131d | start no earlier than 2005-04-25 | Campus Review Committee | 40h |
| 23 | 1.3.6.4 | Circulation of first draft for comment | 1d | 2005-05-09 | 2005-05-09 | 125d | start no earlier than 2005-05-09 | Campus Review Committee | 8h |
| 24 | 1.3.6.5 | Comment from Campus | 5d | 2005-05-09 | 2005-05-13 | 121d | start no earlier than 2005-05-09 | Campus Review Committee | 40h |
| 25 | 1.3.6.6 | Development of second draft | 10d | 2005-05-16 | 2005-05-27 | 111d | start no earlier than 2005-05-16 | Campus Review Committee | 80h |
| 26 | 1.3.6.7 | Circulation of second draft for comment | 1d | 2005-05-30 | 2005-05-30 | 110d | start no earlier than 2005-05-30 | Campus Review Committee | 8h |
| 27 | 1.3.6.8 | Comments on second draft | 5d | 2005-05-30 | 2005-06-03 | 106d | start no earlier than 2005-05-30 | Campus Review Committee | 40h |
| 28 | 1.3.6.9 | Compilation of final draft, appendices, and supporting documentation | 10d | 2005-06-06 | 2005-06-17 | 96d | start no earlier than 2005-06-06 | Campus Review Committee | 80h |
| 29 | 1.3.6.10 | Campus signs of final copy | 1d | 2005-06-17 | 2005-06-17 | 96d | start no earlier than 2005-06-17 | Campus Review Committee | 8h |
| 30 | 1.3.6.11 | Campus submits portfolio to DQP | 1d | 2005-06-20 | 2005-06-20 | 95d | start no earlier than 2005-06-20 | Campus Review Committee | 8h |
| 31 | 1.4 | Appointment of review panel | 5d | 2005-05-23 | 2005-05-27 | 111d | start no earlier than 2005-05-23 | DQP | 40h |
| 32 | 1.5 | Orienatation of panel members on portfolio review | 5d | 2005-06-06 | 2005-06-10 | 101d | start no earlier than 2005-06-06 | DQP | 40h |
| 33 | 1.6 | Distribution of portfolio to review panel | 5d | 2005-06-20 | 2005-06-24 | 91d | start no earlier than 2005-06-20 | DQP | 40h |
| 34 | 1.7 | Panel members analyse portfolio | 15d | 2005-06-20 | 2005-07-08 | 81d | start no earlier than 2005-06-20 | Panel Members | 120h |
| 35 | 1.8 | Finalise site visit programme and logistics | 5d | 2005-06-06 | 2005-06-10 | 101d | start no earlier than 2005-06-06 | DQP; Faculty Office | 80h |
| 36 | 1.9 | Orientation of panel members and portfolio meeting | 5d | 2005-06-13 | 2005-06-17 | 96d | start no earlier than 2005-06-13 | DQP | 40h |
| 37 | 1.10 | Site Visits | 5d | 2005-06-20 | 2005-06-24 | 91d | start no earlier than 2005-06-20 | DQP; Panel Members | 80h |
| 38 | 1.11 | Compilation of first draft of review report | 10d | 2005-07-04 | 2005-07-15 | 76d | start no earlier than 2005-07-04 | DQP | 80h |
| 39 | 1.12 | First draft to panel members for comment | 1d | 2005-07-29 | 2005-07-29 | 66d | finish no earlier than 2005-07-29 | DQP | 8h |
| 40 | 1.13 | Members comments to DQP | 5d | 2005-08-01 | 2005-08-05 | 61d | finish no earlier than 2005-08-05 | Panel Members | 40h |
| 41 | 1.14 | Compilation of second draft of review report | 10d | 2005-08-08 | 2005-08-19 | 51d | start no earlier than 2005-08-08 | DQP | 80h |
| 42 | 1.15 | Second draft to panel members and Campus | 1d | 2005-08-31 | 2005-08-31 | 43d | finish no earlier than 2005-08-31 | DQP | 8h |
| 43 | 1.16 | Comments to DQP | 5d | 2005-09-05 | 2005-09-09 | 36d | finish no earlier than 2005-09-09 | Panel Members; Campus Review Committee | 80h |
| 44 | 1.17 | Final copy | 10d | 2005-09-12 | 2005-09-23 | 26d | start no earlier than 2005-09-12 | DQP | 80h |
| 45 | 1.18 | Final copy to DVC, Campus Director | 1d | 2005-09-26 | 2005-09-26 | 25d | start no earlier than 2005-09-26 | DQP | 8h |
| 46 | 1.19 | Campus Improvement plan to DVC, DQP | 1d | 2005-10-31 | 2005-10-31 | 0d | start no earlier than 2005-10-31 | Campus Review Committee | 8h |
